# 2023-10-24 AJUSTE PROGRAMACION UDS

Schedule from MS Project, 2023-10-23 to 2024-05-22.

## Calendars

- 5 DIAS LABORALES: Mon-Fri 09:00-13:00, 15:00-19:00; Sat-Sun off.

## Resources

| Resource |
| --- |
| + |
| 46 |

## Schedule

| ID | WBS | Task | Type | Duration | Start | Finish | Predecessors | Total slack | Free slack | Constraint |
| --- | --- | --- | --- | --- | --- | --- | --- | --- | --- | --- |
| 1 | 1 | **CRONOGRAMA UNIDAD DEPORTIVA EL SALITRE** |  | 153d | 2023-10-23 | 2024-05-22 |  | 0d |  |  |
| 2 | 1.1 | **20 % ESQUEMA BASICO** |  | 77d | 2023-10-23 | 2024-02-06 |  | 7d |  |  |
| 3 | 1.1.1 | **Programa de diseño** |  | 40d | 2023-11-01 | 2023-12-26 |  | 0d |  |  |
| 4 | 1.1.1.1 | Entrega esquema basico programa arquitectónico |  | 30d | 2023-11-01 | 2023-12-12 |  | 0d |  | start no earlier than 2023-11-01 |
| 5 | 1.1.1.2 | Revisión por parte de interventoría |  | 5d | 2023-12-13 | 2023-12-19 | 4 | 0d |  |  |
| 6 | 1.1.1.3 | Subsanación observaciones de interventoría |  | 5d | 2023-12-20 | 2023-12-26 | 5 | 0d |  |  |
| 7 | 1.1.1.4 | Entrega programa de diseño | milestone | 0d | 2023-12-26 | 2023-12-26 | 6 | 0d |  |  |
| 8 | 1.1.2 | Radicaciones de las consultas a las autoridades competentes. |  | 15d | 2023-10-23 | 2023-11-10 |  | 138d | 0d |  |
| 9 | 1.1.3 | Radicación disponibilidad de servicios públicos |  | 15d | 2023-10-23 | 2023-11-10 | 8SS | 138d |  |  |
| 10 | 1.1.4 | **Informe de análisis patrimonial (Versión 01)** |  | 45d | 2023-11-09 | 2024-01-10 |  |  |  |  |
| 11 | 1.1.4.1 | Actividades de campo |  | 15d | 2023-11-09 | 2023-11-29 |  | 50d | 0d |  |
| 12 | 1.1.4.2 | Elaboración y entrega de informe |  | 20d | 2023-11-30 | 2023-12-27 | 11 | 50d | 0d |  |
| 13 | 1.1.4.3 | Revisión por parte de interventoría |  | 5d | 2023-12-28 | 2024-01-03 | 12 | 50d | 0d |  |
| 14 | 1.1.4.4 | Subsanación observaciones de interventoría |  | 5d | 2024-01-04 | 2024-01-10 | 13 | 50d | 0d |  |
| 15 | 1.1.4.5 | Entrega informe análisis patrimonial | milestone | 0d | 2024-01-10 | 2024-01-10 | 14 | 50d | 0d |  |
| 16 | 1.1.5 | Diagnóstico sobre las condiciones existentes del predio |  | 45d | 2023-11-02 | 2024-01-03 |  | 100d |  | start no earlier than 2023-11-02 |
| 17 | 1.1.6 | **Plan de seguridad y salud en el trabajo** |  | 25d | 2023-10-23 | 2023-11-24 |  | 22d |  |  |
| 18 | 1.1.6.1 | Entrega plan SST |  | 15d | 2023-10-23 | 2023-11-10 |  | 22d | 0d | start no earlier than 2023-10-23 |
| 19 | 1.1.6.2 | Revisión por parte de interventoría |  | 5d | 2023-11-13 | 2023-11-17 | 18 | 22d | 0d |  |
| 20 | 1.1.6.3 | Subsanación observaciones de interventoría |  | 5d | 2023-11-20 | 2023-11-24 | 19 | 22d | 0d |  |
| 21 | 1.1.6.4 | Entrega plan SST | milestone | 0d | 2023-11-24 | 2023-11-24 | 20 | 22d |  |  |
| 22 | 1.1.7 | **Levantamiento topográfico** |  | 61d | 2023-10-23 | 2024-01-15 |  | 92d |  |  |
| 23 | 1.1.7.1 | Metodología de trabajo |  | 11d | 2023-10-23 | 2023-11-06 |  | 92d | 0d |  |
| 24 | 1.1.7.2 | Actividades de campo |  | 25d | 2023-11-07 | 2023-12-11 | 23 | 92d | 0d |  |
| 25 | 1.1.7.3 | Elaboración y entrega de informe |  | 15d | 2023-12-12 | 2024-01-01 | 24 | 92d | 0d |  |
| 26 | 1.1.7.4 | Revisión por parte de interventoría |  | 5d | 2024-01-02 | 2024-01-08 | 25 | 92d | 0d |  |
| 27 | 1.1.7.5 | Subsanación observaciones de interventoría |  | 5d | 2024-01-09 | 2024-01-15 | 26 | 92d | 0d |  |
| 28 | 1.1.7.6 | Entrega topografía | milestone | 0d | 2024-01-15 | 2024-01-15 | 27 | 92d |  |  |
| 29 | 1.1.8 | Estimación basica de cantidades |  | 30d | 2023-12-27 | 2024-02-06 | 7, 21 | 76d |  |  |
| 30 | 1.1.9 | Entrega informe BEP (Plan de ejecución BIM) | milestone | 0d | 2023-11-14 | 2023-11-14 |  | 137d |  | start no earlier than 2023-11-14 |
| 31 | 1.2 | Elaboración y entrega de informes BIM |  | 153d | 2023-10-23 | 2024-05-22 |  | 0d |  | start no earlier than 2023-10-23 |

| ID | WBS | Task | Type | Duration | Start | Finish | Predecessors | Total slack | Free slack | Constraint |
| --- | --- | --- | --- | --- | --- | --- | --- | --- | --- | --- |
| 32 | 1.3 | **Plan de Gestión de Calidad** |  | 153d | 2023-10-23 | 2024-05-22 |  | 0d |  |  |
| 33 | 1.3.1 | Elaboración y entrega de plan de gestión de calidad |  | 15d | 2023-10-23 | 2023-11-10 |  | 128d | 0d |  |
| 34 | 1.3.2 | Revisión por parte de interventoría |  | 5d | 2023-11-13 | 2023-11-17 | 33 | 128d | 0d |  |
| 35 | 1.3.3 | Subsanación observaciones de interventoría |  | 5d | 2023-11-20 | 2023-11-24 | 34 | 128d | 0d |  |
| 36 | 1.3.4 | Entrega plan de gestión de calidad | milestone | 0d | 2023-11-24 | 2023-11-24 | 35 | 128d |  |  |
| 37 | 1.3.5 | **Entrega informe gestión de calidad** |  | 131d | 2023-11-22 | 2024-05-22 |  | 0d |  |  |
| 38 | 1.3.5.1 | Entrega informe gestión de calidad 1 |  | 1d | 2023-11-22 | 2023-11-22 |  | 130d |  | start no earlier than 2023-11-22 |
| 39 | 1.3.5.2 | Entrega informe gestión de calidad 2 |  | 1d | 2023-12-22 | 2023-12-22 |  | 108d |  | start no earlier than 2023-12-22 |
| 40 | 1.3.5.3 | Entrega informe gestión de calidad 3 |  | 1d | 2024-01-22 | 2024-01-22 |  | 87d |  | start no earlier than 2024-01-22 |
| 41 | 1.3.5.4 | Entrega informe gestión de calidad 4 |  | 1d | 2024-02-22 | 2024-02-22 |  | 64d |  | start no earlier than 2024-02-22 |
| 42 | 1.3.5.5 | Entrega informe gestión de calidad 5 |  | 1d | 2024-03-22 | 2024-03-22 |  | 43d |  | start no earlier than 2024-03-22 |
| 43 | 1.3.5.6 | Entrega informe gestión de calidad 6 |  | 1d | 2024-04-22 | 2024-04-22 |  | 22d |  | start no earlier than 2024-04-22 |
| 44 | 1.3.5.7 | Entrega informe gestión de calidad 7 |  | 1d | 2024-05-22 | 2024-05-22 |  | 0d |  | start no earlier than 2024-05-22 |
| 45 | 1.3.6 | Entrega informe final de gestión de calidad |  | 1d | 2024-05-22 | 2024-05-22 |  | 0d |  | start no earlier than 2024-05-22 |
| 46 | 1.4 | **Programa de Gestión social** |  | 153d | 2023-10-23 | 2024-05-22 |  | 0d |  |  |
| 47 | 1.4.1 | **Plan de Gestión social** |  | 23d | 2023-10-23 | 2023-11-22 |  |  |  |  |
| 48 | 1.4.1.1 | Elaboración y entrega de plan de gestión social |  | 15d | 2023-10-23 | 2023-11-10 |  | 130d | 0d |  |
| 49 | 1.4.1.2 | Revisión por parte de interventoría |  | 5d | 2023-11-13 | 2023-11-17 | 48 | 130d | 0d |  |
| 50 | 1.4.1.3 | Subsanación observaciones de interventoría |  | 3d | 2023-11-20 | 2023-11-22 | 49 | 130d | 0d |  |
| 51 | 1.4.1.4 | Entrega plan de gestión social | milestone | 0d | 2023-11-22 | 2023-11-22 | 50 | 130d |  |  |
| 52 | 1.4.2 | Diagnostico Social |  | 45d | 2023-11-15 | 2024-01-16 |  | 91d |  | start no earlier than 2023-11-15 |
| 53 | 1.4.3 | Estudio de mercado |  | 45d | 2023-11-15 | 2024-01-16 |  | 91d |  | start no earlier than 2023-11-15 |
| 54 | 1.4.4 | **Programa información y comunicación** |  | 131d | 2023-11-22 | 2024-05-22 |  | 0d |  |  |
| 55 | 1.4.4.1 | **Reunión con la comunidad** |  | 131d | 2023-11-22 | 2024-05-22 |  | 0d |  |  |
| 56 | 1.4.4.1.1 | Reunión con la comunidad 1 |  | 1d | 2023-11-22 | 2023-11-22 |  | 130d |  | start no earlier than 2023-11-22 |
| 57 | 1.4.4.1.2 | Reunión con la comunidad 2 |  | 1d | 2024-02-22 | 2024-02-22 |  | 64d |  | start no earlier than 2024-02-22 |
| 58 | 1.4.4.1.3 | Reunión con la comunidad 3 |  | 1d | 2024-05-22 | 2024-05-22 |  | 0d |  | start no earlier than 2024-05-22 |

| ID | WBS | Task | Type | Duration | Start | Finish | Predecessors | Total slack | Free slack | Constraint |
| --- | --- | --- | --- | --- | --- | --- | --- | --- | --- | --- |
| 59 | 1.5 | **30% ANTEPROYECTO** |  | 111d | 2023-11-07 | 2024-04-09 |  | 31d |  |  |
| 60 | 1.5.1 | **Estudio Geotécnico** |  | 73d | 2023-11-07 | 2024-02-15 |  | 69d |  |  |
| 61 | 1.5.1.1 | Metodología de trabajo |  | 11d | 2023-11-07 | 2023-11-21 |  | 69d | 0d | start no earlier than 2023-11-07 |
| 62 | 1.5.1.2 | Actividades de campo |  | 25d | 2023-11-22 | 2023-12-26 | 61 | 69d | 0d |  |
| 63 | 1.5.1.3 | Elaboración y entrega de informe |  | 25d | 2023-12-27 | 2024-01-30 | 62 | 69d | 0d |  |
| 64 | 1.5.1.4 | Revisión por parte de interventoría |  | 7d | 2024-01-31 | 2024-02-08 | 63 | 69d | 0d |  |
| 65 | 1.5.1.5 | Subsanación observaciones de interventoría |  | 5d | 2024-02-09 | 2024-02-15 | 64 | 69d | 0d |  |
| 66 | 1.5.1.6 | Entrega estudio geotecnico | milestone | 0d | 2024-02-15 | 2024-02-15 | 65 | 69d |  |  |
| 67 | 1.5.2 | **Anteproyecto Arquitectónico** |  | 30d | 2023-12-27 | 2024-02-06 |  | 0d |  |  |
| 68 | 1.5.2.1 | Elaboración de anteproyecto |  | 20d | 2023-12-27 | 2024-01-23 | 7, 21 | 0d |  | start no earlier than 2023-11-01 |
| 69 | 1.5.2.2 | Revisión por parte de interventoría |  | 5d | 2024-01-24 | 2024-01-30 | 68 | 0d |  |  |
| 70 | 1.5.2.3 | Subsanación observaciones de interventoría |  | 5d | 2024-01-31 | 2024-02-06 | 69 | 0d |  |  |
| 71 | 1.5.2.4 | Entrega anteproyecto arquitectónico | milestone | 0d | 2024-02-06 | 2024-02-06 | 70 | 0d |  |  |
| 72 | 1.5.3 | **Anteproyecto urbanistico y de paisajismo** |  | 30d | 2024-02-07 | 2024-03-19 |  | 46d | 0d |  |
| 73 | 1.5.3.1 | Entrega de anteproyecto |  | 20d | 2024-02-07 | 2024-03-05 | 67 | 46d | 0d | start no earlier than 2023-11-01 |
| 74 | 1.5.3.2 | Revisión por parte de interventoría |  | 5d | 2024-03-06 | 2024-03-12 | 73 | 46d | 0d |  |
| 75 | 1.5.3.3 | Subsanación observaciones de interventoría |  | 5d | 2024-03-13 | 2024-03-19 | 74 | 46d | 0d |  |
| 76 | 1.5.3.4 | Entrega anteproyecto urbanistico y paisajistico | milestone | 0d | 2024-03-19 | 2024-03-19 | 75 | 46d |  |  |
| 77 | 1.5.4 | **Anteproyecto Estructural** |  | 30d | 2024-01-24 | 2024-03-05 |  | 16d | 0d |  |
| 78 | 1.5.4.1 | Entrega de anteproyecto |  | 20d | 2024-01-24 | 2024-02-20 | 67SS+20d | 16d | 0d | start no earlier than 2023-11-01 |
| 79 | 1.5.4.2 | Revisión por parte de interventoría |  | 5d | 2024-02-21 | 2024-02-27 | 78 | 16d | 0d |  |
| 80 | 1.5.4.3 | Subsanación observaciones de interventoría |  | 5d | 2024-02-28 | 2024-03-05 | 79 | 16d | 0d |  |
| 81 | 1.5.4.4 | Entrega anteproyecto estructural | milestone | 0d | 2024-03-05 | 2024-03-05 | 80 | 16d | 0d |  |
| 82 | 1.5.5 | **Estudio De Seguridad Humana** |  | 30d | 2024-01-24 | 2024-03-05 |  | 56d |  |  |
| 83 | 1.5.5.1 | Elaboración y entrega de informe |  | 20d | 2024-01-24 | 2024-02-20 | 77SS | 56d | 0d |  |
| 84 | 1.5.5.2 | Revisión por parte de interventoría |  | 5d | 2024-02-21 | 2024-02-27 | 83 | 56d | 0d |  |
| 85 | 1.5.5.3 | Subsanación observaciones de interventoría |  | 5d | 2024-02-28 | 2024-03-05 | 84 | 56d | 0d |  |
| 86 | 1.5.5.4 | Entrega estudio de seguridad humana | milestone | 0d | 2024-03-05 | 2024-03-05 | 85 | 56d |  |  |

| ID | WBS | Task | Type | Duration | Start | Finish | Predecessors | Total slack | Free slack | Constraint |
| --- | --- | --- | --- | --- | --- | --- | --- | --- | --- | --- |
| 87 | 1.5.6 | **Anteproyecto Eléctricos** |  | 30d | 2024-02-28 | 2024-04-09 |  | 6d | 0d |  |
| 88 | 1.5.6.1 | Entrega de anteproyecto |  | 20d | 2024-02-28 | 2024-03-26 | 77SS+25d | 6d | 0d | start no earlier than 2023-11-01 |
| 89 | 1.5.6.2 | Revisión por parte de interventoría |  | 5d | 2024-03-27 | 2024-04-02 | 88 | 6d | 0d |  |
| 90 | 1.5.6.3 | Subsanación observaciones de interventoría |  | 5d | 2024-04-03 | 2024-04-09 | 89 | 6d | 0d |  |
| 91 | 1.5.6.4 | Entrega anteproyecto eléctrico | milestone | 0d | 2024-04-09 | 2024-04-09 | 90 | 6d | 0d |  |
| 92 | 1.5.7 | **Anteproyecto de Sistemas de Sonido** |  | 30d | 2024-02-28 | 2024-04-09 |  | 6d |  |  |
| 93 | 1.5.7.1 | Entrega de anteproyecto |  | 20d | 2024-02-28 | 2024-03-26 | 87SS | 6d | 0d | start no earlier than 2023-11-01 |
| 94 | 1.5.7.2 | Revisión por parte de interventoría |  | 5d | 2024-03-27 | 2024-04-02 | 93 | 6d | 0d |  |
| 95 | 1.5.7.3 | Subsanación observaciones de interventoría |  | 5d | 2024-04-03 | 2024-04-09 | 94 | 6d | 0d |  |
| 96 | 1.5.7.4 | Entrega anteproyecto de sistema de sonido | milestone | 0d | 2024-04-09 | 2024-04-09 | 95 | 6d | 0d |  |
| 97 | 1.5.8 | **Anteproyecto Red de Voz y Datos** |  | 30d | 2024-02-28 | 2024-04-09 |  | 6d |  |  |
| 98 | 1.5.8.1 | Entrega de anteproyecto |  | 20d | 2024-02-28 | 2024-03-26 | 87SS | 6d | 0d | start no earlier than 2023-11-01 |
| 99 | 1.5.8.2 | Revisión por parte de interventoría |  | 5d | 2024-03-27 | 2024-04-02 | 98 | 6d | 0d |  |
| 100 | 1.5.8.3 | Subsanación observaciones de interventoría |  | 5d | 2024-04-03 | 2024-04-09 | 99 | 6d | 0d |  |
| 101 | 1.5.8.4 | Entrega anteproyecto de red de voz y datos | milestone | 0d | 2024-04-09 | 2024-04-09 | 100 | 6d | 0d |  |
| 102 | 1.5.9 | **Anteproyecto Hidrosanitarios** |  | 30d | 2024-02-28 | 2024-04-09 |  | 6d | 0d |  |
| 103 | 1.5.9.1 | Entrega de anteproyecto |  | 20d | 2024-02-28 | 2024-03-26 | 77SS+25d | 6d | 0d | start no earlier than 2023-11-01 |
| 104 | 1.5.9.2 | Revisión por parte de interventoría |  | 5d | 2024-03-27 | 2024-04-02 | 103 | 6d | 0d |  |
| 105 | 1.5.9.3 | Subsanación observaciones de interventoría |  | 5d | 2024-04-03 | 2024-04-09 | 104 | 6d | 0d |  |
| 106 | 1.5.9.4 | Entrega anteproyecto hidrosanitario | milestone | 0d | 2024-04-09 | 2024-04-09 | 105 | 6d | 0d |  |
| 107 | 1.5.10 | **Anteproyecto Recolección de Aguas Lluvias** |  | 30d | 2024-02-28 | 2024-04-09 |  | 6d |  |  |
| 108 | 1.5.10.1 | Entrega de anteproyecto |  | 20d | 2024-02-28 | 2024-03-26 | 102SS | 6d | 0d | start no earlier than 2023-11-01 |
| 109 | 1.5.10.2 | Revisión por parte de interventoría |  | 5d | 2024-03-27 | 2024-04-02 | 108 | 6d | 0d |  |
| 110 | 1.5.10.3 | Subsanación observaciones de interventoría |  | 5d | 2024-04-03 | 2024-04-09 | 109 | 6d | 0d |  |
| 111 | 1.5.10.4 | Entrega anteproyecto aguas lluvias | milestone | 0d | 2024-04-09 | 2024-04-09 | 110 | 6d | 0d |  |

| ID | WBS | Task | Type | Duration | Start | Finish | Predecessors | Total slack | Free slack | Constraint |
| --- | --- | --- | --- | --- | --- | --- | --- | --- | --- | --- |
| 112 | 1.5.11 | **Anteproyecto Red Contra Incendios** |  | 30d | 2024-02-28 | 2024-04-09 |  | 6d |  |  |
| 113 | 1.5.11.1 | Entrega de anteproyecto |  | 20d | 2024-02-28 | 2024-03-26 | 102SS | 6d | 0d | start no earlier than 2023-11-01 |
| 114 | 1.5.11.2 | Revisión por parte de interventoría |  | 5d | 2024-03-27 | 2024-04-02 | 113 | 6d | 0d |  |
| 115 | 1.5.11.3 | Subsanación observaciones de interventoría |  | 5d | 2024-04-03 | 2024-04-09 | 114 | 6d | 0d |  |
| 116 | 1.5.11.4 | Entrega anteproyecto red contra incendios | milestone | 0d | 2024-04-09 | 2024-04-09 | 115 | 6d | 0d |  |
| 117 | 1.5.12 | **Anteproyecto Sistema de Ventilación Mecánica y Climatización** |  | 30d | 2024-02-28 | 2024-04-09 |  | 6d | 0d |  |
| 118 | 1.5.12.1 | Entrega de anteproyecto |  | 20d | 2024-02-28 | 2024-03-26 | 77SS+25d | 6d | 0d | start no earlier than 2023-11-01 |
| 119 | 1.5.12.2 | Revisión por parte de interventoría |  | 5d | 2024-03-27 | 2024-04-02 | 118 | 6d | 0d |  |
| 120 | 1.5.12.3 | Subsanación observaciones de interventoría |  | 5d | 2024-04-03 | 2024-04-09 | 119 | 6d | 0d |  |
| 121 | 1.5.12.4 | Entrega anteproyecto de sistema de ventilación mecánica y climatización | milestone | 0d | 2024-04-09 | 2024-04-09 | 120 | 6d | 0d |  |
| 122 | 1.5.13 | **Anteproyecto Protección Mecánica** |  | 30d | 2024-02-28 | 2024-04-09 |  | 6d |  |  |
| 123 | 1.5.13.1 | Entrega de anteproyecto |  | 20d | 2024-02-28 | 2024-03-26 | 117SS | 6d | 0d | start no earlier than 2023-11-01 |
| 124 | 1.5.13.2 | Revisión por parte de interventoría |  | 5d | 2024-03-27 | 2024-04-02 | 123 | 6d | 0d |  |
| 125 | 1.5.13.3 | Subsanación observaciones de interventoría |  | 5d | 2024-04-03 | 2024-04-09 | 124 | 6d | 0d |  |
| 126 | 1.5.13.4 | Entrega anteproyecto protección mecánica | milestone | 0d | 2024-04-09 | 2024-04-09 | 125 | 6d | 0d |  |
| 127 | 1.5.14 | **Anteproyecto Red de Gas** |  | 30d | 2024-02-28 | 2024-04-09 |  | 6d |  |  |
| 128 | 1.5.14.1 | Entrega de anteproyecto |  | 20d | 2024-02-28 | 2024-03-26 | 77SS+25d | 6d | 0d | start no earlier than 2023-11-01 |
| 129 | 1.5.14.2 | Revisión por parte de interventoría |  | 5d | 2024-03-27 | 2024-04-02 | 128 | 6d | 0d |  |
| 130 | 1.5.14.3 | Subsanación observaciones de interventoría |  | 5d | 2024-04-03 | 2024-04-09 | 129 | 6d | 0d |  |
| 131 | 1.5.14.4 | Entrega anteproyecto de sistema de sonido | milestone | 0d | 2024-04-09 | 2024-04-09 | 130 | 6d | 0d |  |
| 132 | 1.5.15 | **Estudio previo Bioclimático** |  | 40d | 2024-01-31 | 2024-03-26 |  | 16d |  |  |
| 133 | 1.5.15.1 | Elaboración y entrega de informe |  | 25d | 2024-01-31 | 2024-03-05 | 67SS+25d | 16d | 0d |  |
| 134 | 1.5.15.2 | Revisión por parte de interventoría |  | 5d | 2024-03-06 | 2024-03-12 | 133 | 16d | 0d |  |
| 135 | 1.5.15.3 | Subsanación observaciones de interventoría |  | 10d | 2024-03-13 | 2024-03-26 | 134 | 16d | 0d |  |
| 136 | 1.5.15.4 | Entrega estudio previo bioclimatico | milestone | 0d | 2024-03-26 | 2024-03-26 | 135 | 16d | 0d |  |

| ID | WBS | Task | Type | Duration | Start | Finish | Predecessors | Total slack | Free slack | Constraint |
| --- | --- | --- | --- | --- | --- | --- | --- | --- | --- | --- |
| 137 | 1.5.16 | **Estudio previo Ambiental** |  | 45d | 2023-12-27 | 2024-02-27 |  | 1d | 0d |  |
| 138 | 1.5.16.1 | Actividades de campo |  | 15d | 2023-12-27 | 2024-01-16 | 67SS | 1d | 0d |  |
| 139 | 1.5.16.2 | Elaboración y entrega de informe |  | 20d | 2024-01-17 | 2024-02-13 | 138 | 1d | 0d |  |
| 140 | 1.5.16.3 | Revisión por parte de interventoría |  | 5d | 2024-02-14 | 2024-02-20 | 139 | 1d | 0d |  |
| 141 | 1.5.16.4 | Subsanación observaciones de interventoría |  | 5d | 2024-02-21 | 2024-02-27 | 140 | 1d | 0d |  |
| 142 | 1.5.16.5 | Entrega estudio previo forestal | milestone | 0d | 2024-02-27 | 2024-02-27 | 141 | 1d | 0d |  |
| 143 | 1.5.17 | **Estudio previo Forestal** |  | 45d | 2023-12-27 | 2024-02-27 |  | 21d |  |  |
| 144 | 1.5.17.1 | Actividades de campo |  | 15d | 2023-12-27 | 2024-01-16 | 137SS | 21d | 0d |  |
| 145 | 1.5.17.2 | Elaboración y entrega de informe |  | 20d | 2024-01-17 | 2024-02-13 | 144 | 21d | 0d |  |
| 146 | 1.5.17.3 | Revisión por parte de interventoría |  | 5d | 2024-02-14 | 2024-02-20 | 145 | 21d | 0d |  |
| 147 | 1.5.17.4 | Subsanación observaciones de interventoría |  | 5d | 2024-02-21 | 2024-02-27 | 146 | 21d | 0d |  |
| 148 | 1.5.17.5 | Entrega estudio previo forestal | milestone | 0d | 2024-02-27 | 2024-02-27 | 147 | 21d | 0d |  |
| 149 | 1.5.18 | **Informe de análisis patrimonial (Versión 2)** |  | 45d | 2024-01-11 | 2024-03-13 |  | 50d |  |  |
| 150 | 1.5.18.1 | Elaboración y entrega de informe |  | 35d | 2024-01-11 | 2024-02-28 | 15 | 50d | 0d |  |
| 151 | 1.5.18.2 | Revisión por parte de interventoría |  | 5d | 2024-02-29 | 2024-03-06 | 150 | 50d | 0d |  |
| 152 | 1.5.18.3 | Subsanación observaciones de interventoría |  | 5d | 2024-03-07 | 2024-03-13 | 151 | 50d | 0d |  |
| 153 | 1.5.18.4 | Entrega informe análisis patrimonial | milestone | 0d | 2024-03-13 | 2024-03-13 | 152 | 50d |  |  |
| 154 | 1.5.19 | Acta de paisajismo WR concertado en la mesa de paisajismo JBB-SDA. |  | 20d | 2024-02-21 | 2024-03-19 | 72FF | 46d |  |  |
| 155 | 1.5.20 | Radicacion a IDPC | milestone | 0d | 2024-03-05 | 2024-03-05 | 77FF | 56d |  | start no earlier than 2024-02-23 |
| 156 | 1.5.21 | Radicacion a curaduria | milestone | 0d | 2024-03-19 | 2024-03-19 |  | 47d |  | start no earlier than 2024-03-19 |
| 158 | 1.6 | **30% PROYECTO** |  | 70d | 2024-02-07 | 2024-05-14 |  | 0d |  |  |
| 159 | 1.6.1 | **Diseño Arquitectónico y urbanistico** |  | 45d | 2024-02-07 | 2024-04-09 |  | 1d |  |  |
| 160 | 1.6.1.1 | Elaboración de proyecto |  | 30d | 2024-02-07 | 2024-03-19 | 71 | 1d | 0d | start no earlier than 2023-11-01 |
| 161 | 1.6.1.2 | Revisión por parte de interventoría |  | 5d | 2024-03-20 | 2024-03-26 | 160 | 1d | 0d |  |
| 162 | 1.6.1.3 | Subsanación observaciones de interventoría |  | 10d | 2024-03-27 | 2024-04-09 | 161 | 1d | 0d |  |
| 163 | 1.6.1.4 | Entrega proyecto arquitectónico | milestone | 0d | 2024-04-09 | 2024-04-09 | 162 | 1d | 0d |  |

Notes:
- 155: MES 6 TENER ENCUENTA

| ID | WBS | Task | Type | Duration | Start | Finish | Predecessors | Total slack | Free slack | Constraint |
| --- | --- | --- | --- | --- | --- | --- | --- | --- | --- | --- |
| 164 | 1.6.2 | **Diseño Estructural** |  | 40d | 2024-03-06 | 2024-04-30 |  | 16d |  |  |
| 165 | 1.6.2.1 | Elaboración de proyecto |  | 30d | 2024-03-06 | 2024-04-16 | 81 | 16d | 0d | start no earlier than 2023-11-01 |
| 166 | 1.6.2.2 | Revisión por parte de interventoría |  | 5d | 2024-04-17 | 2024-04-23 | 165 | 16d | 0d |  |
| 167 | 1.6.2.3 | Subsanación observaciones de interventoría |  | 5d | 2024-04-24 | 2024-04-30 | 166 | 16d | 0d |  |
| 168 | 1.6.2.4 | Entrega proyecto Estructural | milestone | 0d | 2024-04-30 | 2024-04-30 | 167 | 16d |  |  |
| 169 | 1.6.3 | **Estudio De Seguridad Humana** |  | 35d | 2024-03-06 | 2024-04-23 |  | 21d |  |  |
| 170 | 1.6.3.1 | Elaboración y entrega de informe |  | 20d | 2024-03-06 | 2024-04-02 | 165SS | 21d | 0d |  |
| 171 | 1.6.3.2 | Revisión por parte de interventoría |  | 5d | 2024-04-03 | 2024-04-09 | 170 | 21d | 0d |  |
| 172 | 1.6.3.3 | Subsanación observaciones de interventoría |  | 10d | 2024-04-10 | 2024-04-23 | 171 | 21d | 0d |  |
| 173 | 1.6.3.4 | Entrega estudio de seguridad humana | milestone | 0d | 2024-04-23 | 2024-04-23 | 172 | 21d |  |  |
| 174 | 1.6.4 | **Diseños Eléctricos** |  | 25d | 2024-04-10 | 2024-05-14 |  | 6d |  |  |
| 175 | 1.6.4.1 | Elaboración de proyecto |  | 15d | 2024-04-10 | 2024-04-30 | 91 | 6d | 0d | start no earlier than 2023-11-01 |
| 176 | 1.6.4.2 | Revisión por parte de interventoría |  | 5d | 2024-05-01 | 2024-05-07 | 175 | 6d | 0d |  |
| 177 | 1.6.4.3 | Subsanación observaciones de interventoría |  | 5d | 2024-05-08 | 2024-05-14 | 176 | 6d | 0d |  |
| 178 | 1.6.4.4 | Entrega proyecto eléctrico | milestone | 0d | 2024-05-14 | 2024-05-14 | 177 | 6d |  |  |
| 179 | 1.6.5 | **Diseños de Sistemas de Sonido** |  | 25d | 2024-04-10 | 2024-05-14 |  | 6d |  |  |
| 180 | 1.6.5.1 | Elaboración de proyecto |  | 15d | 2024-04-10 | 2024-04-30 | 96 | 6d | 0d | start no earlier than 2023-11-01 |
| 181 | 1.6.5.2 | Revisión por parte de interventoría |  | 5d | 2024-05-01 | 2024-05-07 | 180 | 6d | 0d |  |
| 182 | 1.6.5.3 | Subsanación observaciones de interventoría |  | 5d | 2024-05-08 | 2024-05-14 | 181 | 6d | 0d |  |
| 183 | 1.6.5.4 | Entrega proyecto de sistemas de sonido | milestone | 0d | 2024-05-14 | 2024-05-14 | 182 | 6d |  |  |
| 184 | 1.6.6 | **Red de Voz y Datos** |  | 25d | 2024-04-10 | 2024-05-14 |  | 6d |  |  |
| 185 | 1.6.6.1 | Elaboración de proyecto |  | 15d | 2024-04-10 | 2024-04-30 | 101 | 6d | 0d | start no earlier than 2023-11-01 |
| 186 | 1.6.6.2 | Revisión por parte de interventoría |  | 5d | 2024-05-01 | 2024-05-07 | 185 | 6d | 0d |  |
| 187 | 1.6.6.3 | Subsanación observaciones de interventoría |  | 5d | 2024-05-08 | 2024-05-14 | 186 | 6d | 0d |  |
| 188 | 1.6.6.4 | Entrega proyecto de voz y datos | milestone | 0d | 2024-05-14 | 2024-05-14 | 187 | 6d |  |  |

| ID | WBS | Task | Type | Duration | Start | Finish | Predecessors | Total slack | Free slack | Constraint |
| --- | --- | --- | --- | --- | --- | --- | --- | --- | --- | --- |
| 189 | 1.6.7 | **Diseños Hidrosanitarios** |  | 25d | 2024-04-10 | 2024-05-14 |  | 6d |  |  |
| 190 | 1.6.7.1 | Elaboración de proyecto |  | 15d | 2024-04-10 | 2024-04-30 | 106 | 6d | 0d | start no earlier than 2023-11-01 |
| 191 | 1.6.7.2 | Revisión por parte de interventoría |  | 5d | 2024-05-01 | 2024-05-07 | 190 | 6d | 0d |  |
| 192 | 1.6.7.3 | Subsanación observaciones de interventoría |  | 5d | 2024-05-08 | 2024-05-14 | 191 | 6d | 0d |  |
| 193 | 1.6.7.4 | Entrega proyecto hidrosanitario | milestone | 0d | 2024-05-14 | 2024-05-14 | 192 | 6d |  |  |
| 194 | 1.6.8 | **Recolección de Aguas Lluvias** |  | 25d | 2024-04-10 | 2024-05-14 |  | 6d |  |  |
| 195 | 1.6.8.1 | Elaboración de proyecto |  | 15d | 2024-04-10 | 2024-04-30 | 111 | 6d | 0d | start no earlier than 2023-11-01 |
| 196 | 1.6.8.2 | Revisión por parte de interventoría |  | 5d | 2024-05-01 | 2024-05-07 | 195 | 6d | 0d |  |
| 197 | 1.6.8.3 | Subsanación observaciones de interventoría |  | 5d | 2024-05-08 | 2024-05-14 | 196 | 6d | 0d |  |
| 198 | 1.6.8.4 | Entrega proyecto aguas lluvias | milestone | 0d | 2024-05-14 | 2024-05-14 | 197 | 6d |  |  |
| 199 | 1.6.9 | **Red Contra Incendios** |  | 25d | 2024-04-10 | 2024-05-14 |  | 6d |  |  |
| 200 | 1.6.9.1 | Elaboración de proyecto |  | 15d | 2024-04-10 | 2024-04-30 | 116 | 6d | 0d | start no earlier than 2023-11-01 |
| 201 | 1.6.9.2 | Revisión por parte de interventoría |  | 5d | 2024-05-01 | 2024-05-07 | 200 | 6d | 0d |  |
| 202 | 1.6.9.3 | Subsanación observaciones de interventoría |  | 5d | 2024-05-08 | 2024-05-14 | 201 | 6d | 0d |  |
| 203 | 1.6.9.4 | Entrega proyecto red contra incendios | milestone | 0d | 2024-05-14 | 2024-05-14 | 202 | 6d |  |  |
| 204 | 1.6.10 | **Diseño Sistema de Ventilación Mecánica y Climatización.** |  | 25d | 2024-04-10 | 2024-05-14 |  | 6d |  |  |
| 205 | 1.6.10.1 | Elaboración de proyecto |  | 15d | 2024-04-10 | 2024-04-30 | 121 | 6d | 0d | start no earlier than 2023-11-01 |
| 206 | 1.6.10.2 | Revisión por parte de interventoría |  | 5d | 2024-05-01 | 2024-05-07 | 205 | 6d | 0d |  |
| 207 | 1.6.10.3 | Subsanación observaciones de interventoría |  | 5d | 2024-05-08 | 2024-05-14 | 206 | 6d | 0d |  |
| 208 | 1.6.10.4 | Entrega proyecto Sistema de Ventilación Mecánica y Climatización. | milestone | 0d | 2024-05-14 | 2024-05-14 | 207 | 6d |  |  |
| 209 | 1.6.11 | **Protección Mecánica** |  | 25d | 2024-04-10 | 2024-05-14 |  | 6d |  |  |
| 210 | 1.6.11.1 | Elaboración de proyecto |  | 15d | 2024-04-10 | 2024-04-30 | 126 | 6d | 0d | start no earlier than 2023-11-01 |
| 211 | 1.6.11.2 | Revisión por parte de interventoría |  | 5d | 2024-05-01 | 2024-05-07 | 210 | 6d | 0d |  |
| 212 | 1.6.11.3 | Subsanación observaciones de interventoría |  | 5d | 2024-05-08 | 2024-05-14 | 211 | 6d | 0d |  |
| 213 | 1.6.11.4 | Entrega proyecto protección mecanica | milestone | 0d | 2024-05-14 | 2024-05-14 | 212 | 6d |  |  |

| ID | WBS | Task | Type | Duration | Start | Finish | Predecessors | Total slack | Free slack | Constraint |
| --- | --- | --- | --- | --- | --- | --- | --- | --- | --- | --- |
| 214 | 1.6.12 | **Red de Gas** |  | 25d | 2024-04-10 | 2024-05-14 |  | 6d |  |  |
| 215 | 1.6.12.1 | Elaboración de proyecto |  | 15d | 2024-04-10 | 2024-04-30 | 131 | 6d | 0d | start no earlier than 2023-11-01 |
| 216 | 1.6.12.2 | Revisión por parte de interventoría |  | 5d | 2024-05-01 | 2024-05-07 | 215 | 6d | 0d |  |
| 217 | 1.6.12.3 | Subsanación observaciones de interventoría |  | 5d | 2024-05-08 | 2024-05-14 | 216 | 6d | 0d |  |
| 218 | 1.6.12.4 | Entrega proyecto red de gas | milestone | 0d | 2024-05-14 | 2024-05-14 | 217 | 6d |  |  |
| 219 | 1.6.13 | **Estudio Bioclimático** |  | 25d | 2024-03-27 | 2024-04-30 |  | 16d |  |  |
| 220 | 1.6.13.1 | Elaboración y entrega de informe |  | 10d | 2024-03-27 | 2024-04-09 | 136 | 16d | 0d |  |
| 221 | 1.6.13.2 | Revisión por parte de interventoría |  | 5d | 2024-04-10 | 2024-04-16 | 220 | 16d | 0d |  |
| 222 | 1.6.13.3 | Subsanación observaciones de interventoría |  | 10d | 2024-04-17 | 2024-04-30 | 221 | 16d | 0d |  |
| 223 | 1.6.13.4 | Entrega estudio bioclimatico | milestone | 0d | 2024-04-30 | 2024-04-30 | 222 | 16d |  |  |
| 224 | 1.6.14 | **Estudio Ambiental** |  | 40d | 2024-02-28 | 2024-04-23 |  | 1d |  |  |
| 225 | 1.6.14.1 | Elaboración y entrega de informe |  | 25d | 2024-02-28 | 2024-04-02 | 142 | 1d | 0d |  |
| 226 | 1.6.14.2 | Revisión por parte de interventoría |  | 5d | 2024-04-03 | 2024-04-09 | 225 | 1d | 0d |  |
| 227 | 1.6.14.3 | Subsanación observaciones de interventoría |  | 10d | 2024-04-10 | 2024-04-23 | 226 | 1d | 0d |  |
| 228 | 1.6.14.4 | Entrega estudio ambiental | milestone | 0d | 2024-04-23 | 2024-04-23 | 227 | 1d | 0d |  |
| 229 | 1.6.15 | **Estudio Forestal** |  | 40d | 2024-02-28 | 2024-04-23 |  | 21d |  |  |
| 230 | 1.6.15.1 | Elaboración y entrega de informe |  | 25d | 2024-02-28 | 2024-04-02 | 148 | 21d | 0d |  |
| 231 | 1.6.15.2 | Revisión por parte de interventoría |  | 5d | 2024-04-03 | 2024-04-09 | 230 | 21d | 0d |  |
| 232 | 1.6.15.3 | Subsanación observaciones de interventoría |  | 10d | 2024-04-10 | 2024-04-23 | 231 | 21d | 0d |  |
| 233 | 1.6.15.4 | Entrega estudio forestal | milestone | 0d | 2024-04-23 | 2024-04-23 | 232 | 21d |  |  |
| 234 | 1.6.16 | **Diseño de Señalética** |  | 25d | 2024-04-10 | 2024-05-14 |  | 6d | 0d |  |
| 235 | 1.6.16.1 | Elaboración de diseño |  | 15d | 2024-04-10 | 2024-04-30 | 126 | 6d | 0d | start no earlier than 2023-11-01 |
| 236 | 1.6.16.2 | Revisión por parte de interventoría |  | 5d | 2024-05-01 | 2024-05-07 | 235 | 6d | 0d |  |
| 237 | 1.6.16.3 | Subsanación observaciones de interventoría |  | 5d | 2024-05-08 | 2024-05-14 | 236 | 6d | 0d |  |
| 238 | 1.6.16.4 | Entrega diseño señalética | milestone | 0d | 2024-05-14 | 2024-05-14 | 237 | 6d |  |  |

| ID | WBS | Task | Type | Duration | Start | Finish | Predecessors | Total slack | Free slack |
| --- | --- | --- | --- | --- | --- | --- | --- | --- | --- |
| 239 | 1.6.17 | **Plan de manejo de transito (PMT)** |  | 25d | 2024-04-10 | 2024-05-14 |  | 6d |  |
| 240 | 1.6.17.1 | Actividades de campo |  | 5d | 2024-04-10 | 2024-04-16 | 234SS | 6d | 0d |
| 241 | 1.6.17.2 | Elaboración y entrega de informe |  | 10d | 2024-04-17 | 2024-04-30 | 240 | 6d | 0d |
| 242 | 1.6.17.3 | Revisión por parte de interventoría |  | 5d | 2024-05-01 | 2024-05-07 | 241 | 6d | 0d |
| 243 | 1.6.17.4 | Subsanación observaciones de interventoría |  | 5d | 2024-05-08 | 2024-05-14 | 242 | 6d | 0d |
| 244 | 1.6.17.5 | Entrega PMT | milestone | 0d | 2024-05-14 | 2024-05-14 | 243 | 6d |  |
| 245 | 1.6.18 | Soportes de Bogotá Construcción sostenible |  | 10d | 2024-04-24 | 2024-05-07 | 228 | 1d | 0d |
| 246 | 1.6.19 | **Estudio de Mercado** |  | 45d | 2024-02-07 | 2024-04-09 |  | 0d |  |
| 247 | 1.6.19.1 | Elaboración y entrega de informe |  | 30d | 2024-02-07 | 2024-03-19 | 71 | 0d |  |
| 248 | 1.6.19.2 | Revisión por parte de interventoría |  | 5d | 2024-03-20 | 2024-03-26 | 247 | 0d |  |
| 249 | 1.6.19.3 | Subsanación observaciones de interventoría |  | 10d | 2024-03-27 | 2024-04-09 | 248 | 0d |  |
| 250 | 1.6.19.4 | Entrega estudio de mercado | milestone | 0d | 2024-04-09 | 2024-04-09 | 249 | 0d |  |
| 252 | 1.7 | **10% PRESUPUESTO Y FINALES** |  | 61d | 2024-02-28 | 2024-05-22 |  | 0d |  |
| 253 | 1.7.1 | **Ajustes a diseños arquitectonicos y tecnicos** |  | 30d | 2024-04-10 | 2024-05-21 |  | 1d |  |
| 254 | 1.7.1.1 | Elaboración y entrega de ajustes |  | 20d | 2024-04-10 | 2024-05-07 | 163 | 1d | 0d |
| 255 | 1.7.1.2 | Revisión por parte de interventoría |  | 5d | 2024-05-08 | 2024-05-14 | 254 | 1d | 0d |
| 256 | 1.7.1.3 | Subsanación observaciones de interventoría |  | 5d | 2024-05-15 | 2024-05-21 | 255 | 1d | 0d |
| 257 | 1.7.1.4 | Entrega diseños arquitectonicos y tecnicos | milestone | 0d | 2024-05-21 | 2024-05-21 | 256 | 1d |  |
| 258 | 1.7.2 | **Presupuesto** |  | 41d | 2024-03-27 | 2024-05-22 |  | 0d |  |
| 259 | 1.7.2.1 | Elaboración de presupuesto |  | 31d | 2024-03-27 | 2024-05-08 | 248 | 0d |  |
| 260 | 1.7.2.2 | Revisión por parte de interventoría |  | 5d | 2024-05-09 | 2024-05-15 | 259 | 0d |  |
| 261 | 1.7.2.3 | Subsanación observaciones de interventoría |  | 5d | 2024-05-16 | 2024-05-22 | 260 | 0d |  |
| 262 | 1.7.2.4 | Entrega de presupuesto | milestone | 0d | 2024-05-22 | 2024-05-22 | 261 | 0d |  |
| 263 | 1.7.3 | **Presupuesto y Plan de Gestión de Residuos de Construcción y Demolición – PGRCD** |  | 20d | 2024-03-27 | 2024-04-23 |  | 21d |  |
| 264 | 1.7.3.1 | Elaboración de presupuesto |  | 10d | 2024-03-27 | 2024-04-09 | 259SS | 21d | 0d |
| 265 | 1.7.3.2 | Revisión por parte de interventoría |  | 5d | 2024-04-10 | 2024-04-16 | 264 | 21d | 0d |
| 266 | 1.7.3.3 | Subsanación observaciones de interventoría |  | 5d | 2024-04-17 | 2024-04-23 | 265 | 21d | 0d |
| 267 | 1.7.3.4 | Entrega de presupuesto plan de gestion de residuos de construccion y demolición | milestone | 0d | 2024-04-23 | 2024-04-23 | 266 | 21d |  |

| ID | WBS | Task | Type | Duration | Start | Finish | Predecessors | Total slack | Free slack |
| --- | --- | --- | --- | --- | --- | --- | --- | --- | --- |
| 268 | 1.7.4 | **Programación de Obra** |  | 10d | 2024-04-10 | 2024-04-23 |  | 21d |  |
| 269 | 1.7.4.1 | Elaboración de programación |  | 5d | 2024-04-10 | 2024-04-16 | 249 | 21d | 0d |
| 270 | 1.7.4.2 | Revisión por parte de interventoría |  | 2d | 2024-04-17 | 2024-04-18 | 269 | 21d | 0d |
| 271 | 1.7.4.3 | Subsanación observaciones de interventoría |  | 3d | 2024-04-19 | 2024-04-23 | 270 | 21d | 0d |
| 272 | 1.7.4.4 | Entrega de presupuesto | milestone | 0d | 2024-04-23 | 2024-04-23 | 271 | 21d |  |
| 273 | 1.7.5 | **Flujo de Inversión** |  | 10d | 2024-04-10 | 2024-04-23 |  | 21d |  |
| 274 | 1.7.5.1 | Elaboración de programación |  | 5d | 2024-04-10 | 2024-04-16 | 269SS | 21d | 0d |
| 275 | 1.7.5.2 | Revisión por parte de interventoría |  | 2d | 2024-04-17 | 2024-04-18 | 274 | 21d | 0d |
| 276 | 1.7.5.3 | Subsanación observaciones de interventoría |  | 3d | 2024-04-19 | 2024-04-23 | 275 | 21d | 0d |
| 277 | 1.7.5.4 | Entrega de flujo de inversión | milestone | 0d | 2024-04-23 | 2024-04-23 | 276 | 21d |  |
| 278 | 1.7.6 | **Manual de Especificaciones Técnicas de Obra** |  | 31d | 2024-04-10 | 2024-05-22 |  | 0d |  |
| 279 | 1.7.6.1 | Elaboración de presupuesto |  | 20d | 2024-04-10 | 2024-05-07 | 250 | 0d |  |
| 280 | 1.7.6.2 | Revisión por parte de interventoría |  | 5d | 2024-05-08 | 2024-05-14 | 279 | 0d |  |
| 281 | 1.7.6.3 | Subsanación observaciones de interventoría |  | 6d | 2024-05-15 | 2024-05-22 | 280 | 0d |  |
| 282 | 1.7.6.4 | Entrega de manual de especificaciones técnicas de obra | milestone | 0d | 2024-05-22 | 2024-05-22 | 281 | 0d |  |
| 283 | 1.7.7 | **Plan de Manejo de Flora y Fauna** |  | 45d | 2024-02-28 | 2024-04-30 |  | 16d |  |
| 284 | 1.7.7.1 | Elaboración del programa de flora y fauna |  | 30d | 2024-02-28 | 2024-04-09 | 225SS | 16d | 0d |
| 285 | 1.7.7.2 | Revisión por parte de interventoría |  | 5d | 2024-04-10 | 2024-04-16 | 284 | 16d | 0d |
| 286 | 1.7.7.3 | Subsanación observaciones de interventoría |  | 10d | 2024-04-17 | 2024-04-30 | 285 | 16d | 0d |
| 287 | 1.7.7.4 | Entrega del programa de flora y fauna | milestone | 0d | 2024-04-30 | 2024-04-30 | 286 | 16d |  |
| 288 | 1.7.8 | Soportes de Bogotá Construcción sostenible |  | 10d | 2024-05-08 | 2024-05-21 | 245 | 1d |  |
